# Módulo de Repuestos

Schedule from MS Project, 2019-09-16 to 2020-06-08, costs in $.

## Calendars

- Standard: Mon-Fri 09:00-13:00, 15:00-19:00; Sat-Sun off. Exceptions (off unless hours are given): 2019-10-14 (Festivo), 2019-11-04 (Festivo), 2019-11-11 (Festivo), 2019-12-25 (Festivo), 2020-01-01 (Festivo), 2020-01-06 (Festivo), 2020-03-23 (Festivo), 2020-04-09 to 2020-04-10 (Festivo), 2020-05-01 (Festivo), 2020-05-25 (Festivo).

## Resources

| Resource | Rate |
| --- | --- |
| Arquitecto de Software | 90000 |
| Desarrollador Senior 1 | 87000 |
| Analista QA Senior 1 | 39000 |
| Jeniffer Cruz | 4000 |
| Angel Pereira | 12000 |
| Product Owner | 58000 |
| Scrum Master | 58000 |
| Desarrollador Senior 2 | 87000 |
| Analista QA Senior 2 | 39000 |
| Estefanía Castillo | 4000 |
| Alquiler Equipos Admin | 5040000 |
| Alquiler Equipos Proyecto | 3600000 |

## Schedule

| ID | WBS | Task | Type | Duration | Start | Finish | Predecessors | Baseline start | Baseline finish | Baseline duration | Total slack | Free slack | Constraint | Resources | Work | Cost | Baseline cost |
| --- | --- | --- | --- | --- | --- | --- | --- | --- | --- | --- | --- | --- | --- | --- | --- | --- | --- |
| 1 | 1 | **Desarrollo de Funcionalidad** |  | 58d | 2020-01-20 | 2020-04-14 |  | 2020-01-20 | 2020-05-22 | 86d | 0d |  |  |  | 1280h | 73,688,000 | 166,352,000 |
| 2 | 1.1 | Inicio de Ejecución | milestone | 0d | 2020-01-20 | 2020-01-20 | 209 | 2020-01-20 | 2020-01-20 | 0d | 1d | 0d | start no earlier than 2020-01-20 |  |  |  |  |
| 3 | 1.2 | **Ambientes** |  | 1d | 2020-01-21 | 2020-01-21 |  | 2020-01-20 | 2020-01-22 | 3d | 5d |  |  |  | 8h | 720,000 | 2,304,000 |
| 4 | 1.2.1 | Preparar ambientes |  | 1d | 2020-01-21 | 2020-01-21 | 2 | 2020-01-20 | 2020-01-20 | 1d | 5d | 4d | start no earlier than 2020-01-20 | Arquitecto de Software | 8h | 720,000 | 768,000 |
| 5 | 1.3 | **Sprint 0** |  | 5d | 2020-01-21 | 2020-01-27 |  | 2020-01-20 | 2020-01-29 | 8d | 1d |  |  |  | 192h | 9,936,000 | 7,472,000 |
| 6 | 1.3.1 | Realizar el Inception |  | 1d | 2020-01-21 | 2020-01-21 | 2 | 2020-01-20 | 2020-01-20 | 1d | 5d | 4d |  | Product Owner; Scrum Master | 16h | 928,000 | 1,040,000 |
| 7 | 1.3.2 | Establecer los objetivos del Proyecto |  | 1d | 2020-01-21 | 2020-01-21 | 2 | 2020-01-20 | 2020-01-20 | 1d | 1d | 0d |  | Angel Pereira | 8h | 96,000 | 96,000 |
| 8 | 1.3.3 | Definir el Product Backlog |  | 1d | 2020-01-22 | 2020-01-22 | 7 | 2020-01-21 | 2020-01-21 | 1d | 1d | 0d |  | Product Owner; Scrum Master | 16h | 928,000 | 1,040,000 |
| 9 | 1.3.4 | Capacitación Prácticas de Programación |  | 1d | 2020-01-22 | 2020-01-22 | 7 |  |  |  | 3d | 0d |  | Arquitecto de Software; Desarrollador Senior 1; Desarrollador Senior 2 | 24h | 2,112,000 |  |
| 10 | 1.3.5 | Capacitación Aseguramiento de Calidad |  | 1d | 2020-01-22 | 2020-01-22 | 7 |  |  |  | 3d | 0d |  | Analista QA Senior 1; Analista QA Senior 2; Estefanía Castillo | 24h | 656,000 |  |
| 11 | 1.3.6 | Revisar el plan de Release o Liberación |  | 1d | 2020-01-23 | 2020-01-23 | 8, 9, 10 | 2020-01-24 | 2020-01-24 | 1d | 3d | 2d |  | Angel Pereira | 8h | 96,000 | 1,040,000 |
| 12 | 1.3.7 | Capacitación Scrum: Principios y Valores |  | 1d | 2020-01-23 | 2020-01-23 | 8 | 2020-01-24 | 2020-01-24 | 1d | 3d | 2d |  | Analista QA Senior 1; Analista QA Senior 2; Arquitecto de Software; Desarrollador Senior 1; Desarrollador Senior 2; Estefanía Castillo; Jeniffer Cruz; Scrum Master | 64h | 3,264,000 | 96,000 |
| 13 | 1.3.8 | Actualizar las Historias de Usuario |  | 2d | 2020-01-23 | 2020-01-24 | 8 | 2020-01-27 | 2020-01-28 | 2d | 1d | 0d |  | Product Owner | 16h | 928,000 | 2,080,000 |
| 14 | 1.3.9 | Definir las prioridades del Sprint |  | 1d | 2020-01-27 | 2020-01-27 | 13 | 2020-01-29 | 2020-01-29 | 1d | 1d | 0d |  | Scrum Master; Product Owner | 16h | 928,000 | 1,040,000 |
| 15 | 1.4 | **Formulario de Pedidos y Lista de Pedidos** |  | 27d | 2020-01-27 | 2020-03-04 |  | 2020-01-29 | 2020-03-05 | 26d | 0d |  |  |  | 600h | 37,872,000 | 58,584,000 |
| 16 | 1.4.1 | **Desarrollo Backlog** |  | 27d | 2020-01-27 | 2020-03-04 |  | 2020-01-29 | 2020-03-05 | 26d | 0d |  |  |  | 600h | 37,872,000 | 58,584,000 |
| 17 | 1.4.1.1 | **Sprint 1** |  | 13d | 2020-01-27 | 2020-02-13 |  | 2020-01-29 | 2020-02-17 | 13d | 1d |  |  |  | 280h | 19,832,000 | 27,824,000 |
| 18 | 1.4.1.1.1 | Inicio Sprint 1 | milestone | 0d | 2020-01-27 | 2020-01-27 | 14, 6, 7, 8, 11, 12, 13, 4 | 2020-01-29 | 2020-01-29 | 0d | 1d | 0d |  |  |  |  |  |
| 19 | 1.4.1.1.2 | Realizar Sprint Planning |  | 1d | 2020-01-28 | 2020-01-28 | 18 | 2020-01-30 | 2020-01-30 | 1d | 1d | 0d |  | Analista QA Senior 1; Product Owner; Scrum Master; Desarrollador Senior 2 | 32h | 1,936,000 | 4,352,000 |
| 20 | 1.4.1.1.3 | **Historias de Usuario** |  | 2d | 2020-01-29 | 2020-01-30 |  | 2020-01-31 | 2020-02-05 | 4d | 10d |  |  |  | 32h | 1,856,000 | 4,160,000 |
| 21 | 1.4.1.1.3.1 | Refinar y actualizar Historias de Usuario |  | 2d | 2020-01-29 | 2020-01-30 | 19 | 2020-01-31 | 2020-02-05 | 4d | 10d | 9d |  | Product Owner; Scrum Master | 32h | 1,856,000 | 4,160,000 |
| 22 | 1.4.1.1.4 | **Base de Datos** |  | 3d | 2020-01-29 | 2020-01-31 |  | 2020-01-31 | 2020-02-04 | 3d | 1d |  |  |  | 40h | 3,480,000 | 4,080,000 |
| 23 | 1.4.1.1.4.1 | Crear Tablas y procesos |  | 2d | 2020-01-29 | 2020-01-30 | 19 | 2020-01-31 | 2020-02-04 | 3d | 2d | 1d |  | Desarrollador Senior 1 | 16h | 1,392,000 | 2,040,000 |
| 24 | 1.4.1.1.4.2 | Configurar Procedimientos Almacenados |  | 3d | 2020-01-29 | 2020-01-31 | 19 | 2020-01-31 | 2020-02-04 | 3d | 1d | 0d |  | Desarrollador Senior 2 | 24h | 2,088,000 | 2,040,000 |

| ID | WBS | Task | Type | Duration | Start | Finish | Predecessors | Baseline start | Baseline finish | Baseline duration | Total slack | Free slack | Constraint | Resources | Work | Cost | Baseline cost |
| --- | --- | --- | --- | --- | --- | --- | --- | --- | --- | --- | --- | --- | --- | --- | --- | --- | --- |
| 25 | 1.4.1.1.5 | **Enlace de Datos** |  | 2d | 2020-02-03 | 2020-02-04 |  | 2020-02-05 | 2020-02-07 | 3d | 1d |  |  |  | 32h | 2,784,000 | 4,080,000 |
| 26 | 1.4.1.1.5.1 | Realizar el mapeo de Datos |  | 2d | 2020-02-03 | 2020-02-04 | 23, 24 | 2020-02-05 | 2020-02-07 | 3d | 1d | 0d |  | Desarrollador Senior 1 | 16h | 1,392,000 | 2,040,000 |
| 27 | 1.4.1.1.5.2 | Configurar el agente de servicios (Proxy) |  | 2d | 2020-02-03 | 2020-02-04 | 23, 24 | 2020-02-05 | 2020-02-07 | 3d | 1d | 0d |  | Desarrollador Senior 2 | 16h | 1,392,000 | 2,040,000 |
| 28 | 1.4.1.1.6 | **MVP** |  | 7d | 2020-02-05 | 2020-02-13 |  | 2020-02-10 | 2020-02-17 | 6d | 1d |  |  |  | 144h | 9,776,000 | 11,152,000 |
| 29 | 1.4.1.1.6.1 | Crear Interfaz de Solicitud de Pedido |  | 4d | 2020-02-05 | 2020-02-10 | 23, 24, 26, 27 | 2020-02-10 | 2020-02-12 | 3d | 1d | 0d |  | Desarrollador Senior 1 | 32h | 2,784,000 | 2,040,000 |
| 30 | 1.4.1.1.6.2 | Crear interfaz de listado de pedidos |  | 4d | 2020-02-05 | 2020-02-10 | 23, 24, 26, 27 | 2020-02-10 | 2020-02-12 | 3d | 3d | 2d |  | Desarrollador Senior 2 | 32h | 2,784,000 | 2,040,000 |
| 31 | 1.4.1.1.6.3 | Ajustar campos servicios y Listas desplegables |  | 2d | 2020-02-11 | 2020-02-12 | 23, 24, 26, 27, 29 | 2020-02-13 | 2020-02-14 | 2d | 1d | 0d |  | Desarrollador Senior 1 | 16h | 1,392,000 | 2,720,000 |
| 32 | 1.4.1.1.6.4 | Desplegar versión en ambiente de Pruebas |  | 1d | 2020-02-13 | 2020-02-13 | 29, 30, 31 | 2020-02-17 | 2020-02-17 | 1d | 1d |  |  | Arquitecto de Software | 8h | 720,000 | 768,000 |
| 33 | 1.4.1.1.6.5 | Realizar Sprint Retrospective |  | 1d | 2020-02-13 | 2020-02-13 | 29, 30, 31 | 2020-02-17 | 2020-02-17 | 1d | 1d |  |  | Scrum Master; Angel Pereira; Estefanía Castillo | 24h | 592,000 | 1,880,000 |
| 34 | 1.4.1.1.6.6 | Realizar Sprint Review |  | 1d | 2020-02-13 | 2020-02-13 | 29, 30, 31, 21 | 2020-02-17 | 2020-02-17 | 1d | 1d |  |  | Analista QA Senior 2; Desarrollador Senior 2; Jeniffer Cruz | 24h | 1,040,000 | 1,184,000 |
| 35 | 1.4.1.1.6.7 | Definir las Prioridades del Sprint |  | 1d | 2020-02-13 | 2020-02-13 | 29, 30, 31 | 2020-02-17 | 2020-02-17 | 1d | 1d |  |  | Product Owner | 8h | 464,000 | 520,000 |
| 36 | 1.4.1.2 | **Sprint 2** |  | 13d | 2020-02-17 | 2020-03-04 |  | 2020-02-17 | 2020-03-05 | 13d | 0d |  |  |  | 320h | 18,040,000 | 30,760,000 |
| 37 | 1.4.1.2.1 | Inicio Sprint 2 | milestone | 0d | 2020-02-17 | 2020-02-17 | 35, 34, 33, 32 | 2020-02-17 | 2020-02-17 | 0d | 0d |  | start no earlier than 2020-02-17 |  |  |  |  |
| 38 | 1.4.1.2.2 | Realizar el Sprint Planning |  | 1d | 2020-02-17 | 2020-02-17 | 37 | 2020-02-18 | 2020-02-18 | 1d | 0d |  |  | Analista QA Senior 2; Desarrollador Senior 2; Product Owner; Scrum Master | 32h | 1,936,000 | 4,352,000 |
| 39 | 1.4.1.2.3 | **Historias de Usuario** |  | 1d | 2020-02-18 | 2020-02-18 |  | 2020-02-19 | 2020-02-24 | 4d | 10d |  |  |  | 16h | 928,000 | 4,160,000 |
| 40 | 1.4.1.2.3.1 | Refinar y actualizar Historias de Usuario |  | 1d | 2020-02-18 | 2020-02-18 | 38 | 2020-02-19 | 2020-02-24 | 4d | 10d |  |  | Product Owner; Scrum Master | 16h | 928,000 | 4,160,000 |
| 41 | 1.4.1.2.4 | **Refinamiento de Desarrollo** |  | 5d | 2020-02-18 | 2020-02-24 |  | 2020-02-19 | 2020-02-27 | 7d | 7d |  |  |  | 64h | 5,568,000 | 7,480,000 |
| 42 | 1.4.1.2.4.1 | Refinar y ajustar procedimientos |  | 1d | 2020-02-18 | 2020-02-18 | 38 | 2020-02-19 | 2020-02-24 | 4d | 9d | 0d |  | Desarrollador Senior 1 | 8h | 696,000 | 5,440,000 |
| 43 | 1.4.1.2.4.2 | Crear SP de Integraciones |  | 2d | 2020-02-19 | 2020-02-20 | 42 | 2020-02-25 | 2020-02-27 | 3d | 9d |  |  | Desarrollador Senior 1 | 16h | 1,392,000 | 2,040,000 |
| 44 | 1.4.1.2.4.3 | Realizar pruebas de Concepto Integración |  | 5d | 2020-02-18 | 2020-02-24 | 38 |  |  |  | 7d |  |  | Desarrollador Senior 2 | 40h | 3,480,000 |  |
| 45 | 1.4.1.2.5 | **Pruebas Funcionales** |  | 4d | 2020-02-18 | 2020-02-21 |  | 2020-02-19 | 2020-02-24 | 4d | 0d |  |  |  | 32h | 1,248,000 | 2,368,000 |
| 46 | 1.4.1.2.5.1 | Realizar las pruebas funcionales de las pantallas de solicitud y listado |  | 2d | 2020-02-18 | 2020-02-19 | 38 | 2020-02-19 | 2020-02-20 | 2d | 0d |  |  | Analista QA Senior 1 | 16h | 624,000 | 1,184,000 |
| 47 | 1.4.1.2.5.2 | Reportar Incidencias |  | 1d | 2020-02-20 | 2020-02-20 | 46 | 2020-02-21 | 2020-02-21 | 1d | 0d |  |  | Analista QA Senior 1 | 8h | 312,000 | 592,000 |
| 48 | 1.4.1.2.5.3 | Documentar pruebas realizadas con evidencias |  | 1d | 2020-02-21 | 2020-02-21 | 47 | 2020-02-24 | 2020-02-24 | 1d | 0d |  |  | Analista QA Senior 1 | 8h | 312,000 | 592,000 |

| ID | WBS | Task | Type | Duration | Start | Finish | Predecessors | Baseline start | Baseline finish | Baseline duration | Total slack | Resources | Work | Cost | Baseline cost |
| --- | --- | --- | --- | --- | --- | --- | --- | --- | --- | --- | --- | --- | --- | --- | --- |
| 49 | 1.4.1.2.6 | **Pruebas Técnicas** |  | 7d | 2020-02-18 | 2020-02-26 |  | 2020-02-19 | 2020-02-27 | 7d | 0d |  | 56h | 3,360,000 | 4,496,000 |
| 50 | 1.4.1.2.6.1 | Realizar las pruebas técnicas del comportamiento de los pedidos |  | 2d | 2020-02-18 | 2020-02-19 | 38 | 2020-02-19 | 2020-02-20 | 2d | 0d | Analista QA Senior 2 | 16h | 624,000 | 1,184,000 |
| 51 | 1.4.1.2.6.2 | Reportar Incidencias |  | 1d | 2020-02-20 | 2020-02-20 | 50 | 2020-02-21 | 2020-02-21 | 1d | 0d | Analista QA Senior 2 | 8h | 312,000 | 592,000 |
| 52 | 1.4.1.2.6.3 | Documentar pruebas realizadas con evidencias |  | 1d | 2020-02-21 | 2020-02-21 | 51 | 2020-02-24 | 2020-02-24 | 1d | 0d | Analista QA Senior 2 | 8h | 312,000 | 592,000 |
| 53 | 1.4.1.2.6.4 | Resolver Incidencias y Refinar desarrollos |  | 2d | 2020-02-24 | 2020-02-25 | 47, 51, 48, 52 | 2020-02-25 | 2020-02-26 | 2d | 0d | Desarrollador Senior 1 | 16h | 1,392,000 | 1,360,000 |
| 54 | 1.4.1.2.6.5 | Desplegar nueva versión QA |  | 1d | 2020-02-26 | 2020-02-26 | 53 | 2020-02-27 | 2020-02-27 | 1d | 0d | Arquitecto de Software | 8h | 720,000 | 768,000 |
| 55 | 1.4.1.2.7 | **Pruebas de Certificación** |  | 1d | 2020-02-27 | 2020-02-27 |  | 2020-02-28 | 2020-02-28 | 1d | 0d |  | 16h | 624,000 | 1,184,000 |
| 56 | 1.4.1.2.7.1 | Certificar HU funcionalmente |  | 1d | 2020-02-27 | 2020-02-27 | 54 | 2020-02-28 | 2020-02-28 | 1d | 0d | Analista QA Senior 1; Analista QA Senior 2 | 16h | 624,000 | 1,184,000 |
| 57 | 1.4.1.2.8 | **Release 1** |  | 4d | 2020-02-28 | 2020-03-04 |  | 2020-03-02 | 2020-03-05 | 4d | 0d |  | 104h | 4,376,000 | 6,720,000 |
| 58 | 1.4.1.2.8.1 | Desplegar versión en Simulador |  | 1d | 2020-02-28 | 2020-02-28 | 56 | 2020-03-02 | 2020-03-02 | 1d | 0d | Arquitecto de Software | 8h | 720,000 | 768,000 |
| 59 | 1.4.1.2.8.2 | Certificar HU en Simulador |  | 2d | 2020-03-02 | 2020-03-03 | 58 | 2020-03-03 | 2020-03-04 | 2d | 0d | Analista QA Senior 1; Analista QA Senior 2 | 32h | 1,248,000 | 2,368,000 |
| 60 | 1.4.1.2.8.3 | Versión Liberada | milestone | 0d | 2020-03-03 | 2020-03-03 | 59 | 2020-03-04 | 2020-03-04 | 0d | 0d |  |  |  |  |
| 61 | 1.4.1.2.8.4 | Realizar Sprint Review |  | 1d | 2020-03-04 | 2020-03-04 | 60, 40 | 2020-03-05 | 2020-03-05 | 1d | 0d | Analista QA Senior 1; Jeniffer Cruz | 16h | 344,000 | 592,000 |
| 62 | 1.4.1.2.8.5 | Realizar pruebas de usuario |  | 1d | 2020-03-04 | 2020-03-04 | 60 | 2020-03-05 | 2020-03-05 | 1d | 0d | Analista QA Senior 2 | 8h | 312,000 | 592,000 |
| 63 | 1.4.1.2.8.6 | Realizar Retrospective Sprint |  | 1d | 2020-03-04 | 2020-03-04 | 60 | 2020-03-05 | 2020-03-05 | 1d | 0d | Scrum Master; Desarrollador Senior 2; Angel Pereira; Estefanía Castillo | 32h | 1,288,000 | 1,880,000 |
| 64 | 1.4.1.2.8.7 | Definir las Prioridades del Sprint |  | 1d | 2020-03-04 | 2020-03-04 | 60 | 2020-03-05 | 2020-03-05 | 1d | 0d | Product Owner | 8h | 464,000 | 520,000 |
| 65 | 1.5 | **Integraciones y Reportes** |  | 26d | 2020-03-04 | 2020-04-14 |  | 2020-03-05 | 2020-04-15 | 26d | 0d |  | 480h | 25,160,000 | 55,856,000 |
| 66 | 1.5.1 | **Desarrollo del Backlog** |  | 26d | 2020-03-04 | 2020-04-14 |  | 2020-03-05 | 2020-04-15 | 26d | 0d |  | 480h | 25,160,000 | 55,856,000 |
| 67 | 1.5.1.1 | **Sprint 3** |  | 13d | 2020-03-04 | 2020-03-24 |  | 2020-03-05 | 2020-03-25 | 13d | 0d |  | 216h | 11,504,000 | 24,200,000 |
| 68 | 1.5.1.1.1 | Inicio Sprint 3 | milestone | 0d | 2020-03-04 | 2020-03-04 | 61, 62, 63, 64 | 2020-03-05 | 2020-03-05 | 0d | 0d |  |  |  |  |
| 69 | 1.5.1.1.2 | Realizar el Sprint Planning |  | 1d | 2020-03-05 | 2020-03-05 | 68, 42, 43, 44 | 2020-03-06 | 2020-03-06 | 1d | 0d | Analista QA Senior 1; Desarrollador Senior 2; Product Owner; Scrum Master | 32h | 1,936,000 | 4,352,000 |
| 70 | 1.5.1.1.3 | **Historias de Usuario** |  | 1d | 2020-03-06 | 2020-03-06 |  | 2020-03-09 | 2020-03-13 | 5d | 11d |  | 8h | 464,000 | 2,600,000 |
| 71 | 1.5.1.1.3.1 | Refinar y actualizar Historias de Usuario |  | 1d | 2020-03-06 | 2020-03-06 | 69 | 2020-03-09 | 2020-03-13 | 5d | 11d | Product Owner | 8h | 464,000 | 2,600,000 |
| 72 | 1.5.1.1.4 | **Base de Datos** |  | 4d | 2020-03-06 | 2020-03-11 |  | 2020-03-09 | 2020-03-11 | 3d | 0d |  | 32h | 2,784,000 | 2,720,000 |
| 73 | 1.5.1.1.4.1 | Construir procedimientos Integración Agendar |  | 2d | 2020-03-06 | 2020-03-09 | 69 | 2020-03-09 | 2020-03-09 | 1d | 0d | Desarrollador Senior 1 | 16h | 1,392,000 | 680,000 |
| 74 | 1.5.1.1.4.2 | Construir procedimientos Ejecutar |  | 1d | 2020-03-10 | 2020-03-10 | 73 | 2020-03-09 | 2020-03-09 | 1d | 0d | Desarrollador Senior 2 | 8h | 696,000 | 680,000 |
| 75 | 1.5.1.1.4.3 | Configurar servicio de Carga Masiva |  | 1d | 2020-03-11 | 2020-03-11 | 73, 74 | 2020-03-10 | 2020-03-11 | 2d | 0d | Desarrollador Senior 1 | 8h | 696,000 | 1,360,000 |

| ID | WBS | Task | Type | Duration | Start | Finish | Predecessors | Baseline start | Baseline finish | Baseline duration | Total slack | Resources | Work | Cost | Baseline cost |
| --- | --- | --- | --- | --- | --- | --- | --- | --- | --- | --- | --- | --- | --- | --- | --- |
| 76 | 1.5.1.1.5 | **MVP** |  | 2d | 2020-03-12 | 2020-03-13 |  | 2020-03-12 | 2020-03-16 | 3d | 0d |  | 16h | 1,416,000 | 2,040,000 |
| 77 | 1.5.1.1.5.1 | Ajustar campos en Interfaz gráfica |  | 1d | 2020-03-12 | 2020-03-12 | 75 | 2020-03-12 | 2020-03-13 | 2d | 0d | Desarrollador Senior 1 | 8h | 696,000 | 1,360,000 |
| 78 | 1.5.1.1.5.2 | Desplegar versión |  | 1d | 2020-03-13 | 2020-03-13 | 77 |  |  |  | 0d | Arquitecto de Software | 8h | 720,000 |  |
| 79 | 1.5.1.1.6 | **Pruebas Funcionales** |  | 6d | 2020-03-16 | 2020-03-24 |  | 2020-03-18 | 2020-03-25 | 5d | 0d |  | 128h | 4,904,000 | 8,320,000 |
| 80 | 1.5.1.1.6.1 | Validar la funcionalidad de carga masiva |  | 4d | 2020-03-16 | 2020-03-19 | 78 | 2020-03-18 | 2020-03-19 | 2d | 0d | Analista QA Senior 1 | 32h | 1,248,000 | 1,184,000 |
| 81 | 1.5.1.1.6.2 | Validar ajustes de servicios y procesos |  | 3d | 2020-03-16 | 2020-03-18 | 78 | 2020-03-18 | 2020-03-19 | 2d | 1d | Analista QA Senior 2 | 24h | 936,000 | 1,184,000 |
| 82 | 1.5.1.1.6.3 | Reportar Incidencias |  | 1d | 2020-03-20 | 2020-03-20 | 80, 81 | 2020-03-20 | 2020-03-24 | 2d | 0d | Analista QA Senior 1; Analista QA Senior 2 | 16h | 624,000 | 2,368,000 |
| 83 | 1.5.1.1.6.4 | Realizar Sprint Review |  | 1d | 2020-03-24 | 2020-03-24 | 82 | 2020-03-25 | 2020-03-25 | 1d | 0d | Analista QA Senior 1; Estefanía Castillo; Jeniffer Cruz | 24h | 376,000 | 1,184,000 |
| 84 | 1.5.1.1.6.5 | Realizar Sprint Retrospective |  | 1d | 2020-03-24 | 2020-03-24 | 82 | 2020-03-25 | 2020-03-25 | 1d | 0d | Desarrollador Senior 2; Scrum Master; Angel Pereira | 24h | 1,256,000 | 1,880,000 |
| 85 | 1.5.1.1.6.6 | Definir las prioridades del Sprint |  | 1d | 2020-03-24 | 2020-03-24 | 82 | 2020-03-25 | 2020-03-25 | 1d | 0d | Product Owner | 8h | 464,000 | 520,000 |
| 86 | 1.5.1.2 | **Sprint 4** |  | 13d | 2020-03-24 | 2020-04-14 |  | 2020-03-25 | 2020-04-15 | 13d | 0d |  | 264h | 13,656,000 | 31,656,000 |
| 87 | 1.5.1.2.1 | Inicio Sprint 4 | milestone | 0d | 2020-03-24 | 2020-03-24 | 85, 83, 84, 71 | 2020-03-25 | 2020-03-25 | 0d | 0d |  |  |  |  |
| 88 | 1.5.1.2.2 | Realizar Sprint Planning |  | 1d | 2020-03-25 | 2020-03-25 | 87 | 2020-03-26 | 2020-03-26 | 1d | 0d | Analista QA Senior 2; Desarrollador Senior 2; Product Owner; Scrum Master | 32h | 1,936,000 | 4,352,000 |
| 89 | 1.5.1.2.3 | **Reportes** |  | 2d | 2020-03-26 | 2020-03-27 |  | 2020-03-27 | 2020-04-03 | 6d | 0d |  | 32h | 2,784,000 | 8,160,000 |
| 90 | 1.5.1.2.3.1 | Construir base de reportes |  | 1d | 2020-03-26 | 2020-03-26 | 88 | 2020-03-27 | 2020-03-31 | 3d | 0d | Desarrollador Senior 1 | 8h | 696,000 | 4,080,000 |
| 91 | 1.5.1.2.3.2 | Incluir campos de Reportes |  | 1d | 2020-03-27 | 2020-03-27 | 90 | 2020-04-01 | 2020-04-03 | 3d | 0d | Desarrollador Senior 1; Desarrollador Senior 2 | 16h | 1,392,000 | 4,080,000 |
| 92 | 1.5.1.2.3.3 | Ajustar SP de Proceso e Integración |  | 1d | 2020-03-26 | 2020-03-26 | 88 |  |  |  | 1d | Desarrollador Senior 2 | 8h | 696,000 |  |
| 93 | 1.5.1.2.4 | **Pruebas Técnicas** |  | 3d | 2020-03-30 | 2020-04-01 |  | 2020-03-27 | 2020-04-01 | 4d | 0d |  | 24h | 1,344,000 | 2,544,000 |
| 94 | 1.5.1.2.4.1 | Desplegar versión |  | 1d | 2020-03-30 | 2020-03-30 | 88, 91, 92 | 2020-03-27 | 2020-03-27 | 1d | 0d | Arquitecto de Software | 8h | 720,000 | 768,000 |
| 95 | 1.5.1.2.4.2 | Validar técnicamente las Historias de Usuario |  | 2d | 2020-03-31 | 2020-04-01 | 94 | 2020-03-30 | 2020-04-01 | 3d | 0d | Analista QA Senior 1 | 16h | 624,000 | 1,776,000 |
| 96 | 1.5.1.2.5 | **Pruebas de Carga** |  | 2d | 2020-03-31 | 2020-04-01 |  | 2020-03-30 | 2020-04-01 | 3d | 0d |  | 16h | 624,000 | 1,776,000 |
| 97 | 1.5.1.2.5.1 | Realizar pruebas de carga |  | 2d | 2020-03-31 | 2020-04-01 | 94 | 2020-03-30 | 2020-04-01 | 3d | 0d | Analista QA Senior 2 | 16h | 624,000 | 1,776,000 |
| 98 | 1.5.1.2.6 | **Pruebas de Certificación** |  | 3d | 2020-04-02 | 2020-04-06 |  | 2020-04-02 | 2020-04-06 | 3d | 0d |  | 48h | 1,872,000 | 3,552,000 |
| 99 | 1.5.1.2.6.1 | Certificar HU Funcionalmente |  | 3d | 2020-04-02 | 2020-04-06 | 95, 97 | 2020-04-02 | 2020-04-06 | 3d | 0d | Analista QA Senior 1 | 24h | 936,000 | 1,776,000 |
| 100 | 1.5.1.2.6.2 | Certificar HU Técnicamente |  | 3d | 2020-04-02 | 2020-04-06 | 95, 97 | 2020-04-02 | 2020-04-06 | 3d | 0d | Analista QA Senior 2 | 24h | 936,000 | 1,776,000 |

| ID | WBS | Task | Type | Duration | Start | Finish | Predecessors | Baseline start | Baseline finish | Baseline duration | Total slack | Free slack | Resources | Work | Cost | Baseline cost |
| --- | --- | --- | --- | --- | --- | --- | --- | --- | --- | --- | --- | --- | --- | --- | --- | --- |
| 101 | 1.5.1.2.7 | **Release 2** |  | 4d | 2020-04-07 | 2020-04-14 |  | 2020-04-07 | 2020-04-15 | 5d | 0d |  |  | 112h | 5,096,000 | 8,672,000 |
| 102 | 1.5.1.2.7.1 | Desplegar versión en Simulador |  | 1d | 2020-04-07 | 2020-04-07 | 99, 100 | 2020-04-07 | 2020-04-07 | 1d | 0d |  | Arquitecto de Software | 8h | 720,000 | 768,000 |
| 103 | 1.5.1.2.7.2 | Certificar HU en Simulador |  | 2d | 2020-04-08 | 2020-04-13 | 102 | 2020-04-08 | 2020-04-14 | 3d | 0d |  | Analista QA Senior 1; Analista QA Senior 2 | 32h | 1,248,000 | 3,552,000 |
| 104 | 1.5.1.2.7.3 | Versión Liberada | milestone | 0d | 2020-04-13 | 2020-04-13 | 103 | 2020-04-14 | 2020-04-14 | 0d | 0d |  |  |  |  |  |
| 105 | 1.5.1.2.7.4 | Realizar Sprint Review |  | 1d | 2020-04-14 | 2020-04-14 | 104 | 2020-04-15 | 2020-04-15 | 1d | 0d |  | Analista QA Senior 1; Angel Pereira | 16h | 408,000 | 592,000 |
| 106 | 1.5.1.2.7.5 | Realizar pruebas de Usuario |  | 1d | 2020-04-14 | 2020-04-14 | 104 | 2020-04-15 | 2020-04-15 | 1d | 0d |  | Analista QA Senior 2; Product Owner | 16h | 776,000 | 1,112,000 |
| 107 | 1.5.1.2.7.6 | Realizar Sprint Retrospective |  | 1d | 2020-04-14 | 2020-04-14 | 104 | 2020-04-15 | 2020-04-15 | 1d | 0d |  | Desarrollador Senior 2; Scrum Master; Estefanía Castillo; Jeniffer Cruz | 32h | 1,224,000 | 1,880,000 |
| 108 | 1.5.1.2.7.7 | Desplegar versión QA |  | 1d | 2020-04-14 | 2020-04-14 | 104 | 2020-04-15 | 2020-04-15 | 1d | 0d |  | Arquitecto de Software | 8h | 720,000 | 768,000 |
| 109 | 2 | **Plan Guía de Capacitación** |  | 17d | 2020-04-15 | 2020-05-08 |  | 2020-05-26 | 2020-06-17 | 16d | 0d |  |  | 232h | 5,568,000 | 10,240,000 |
| 110 | 2.1 | **Plan de Capacitación** |  | 8d | 2020-04-15 | 2020-04-24 |  | 2020-05-26 | 2020-06-10 | 12d | 0d |  |  | 112h | 3,232,000 | 2,608,000 |
| 111 | 2.1.1 | Realizar plan de capacitación |  | 3d | 2020-04-15 | 2020-04-17 | 105, 106, 107, 108 | 2020-05-26 | 2020-06-05 | 9d | 0d |  | Estefanía Castillo | 24h | 96,000 | 1,152,000 |
| 112 | 2.1.2 | Presentar plan al negocio |  | 3d | 2020-04-20 | 2020-04-22 | 111 | 2020-06-08 | 2020-06-08 | 1d | 0d |  | Angel Pereira; Scrum Master; Product Owner | 72h | 3,072,000 | 1,136,000 |
| 113 | 2.1.3 | Ajustar plan de capacitación |  | 2d | 2020-04-23 | 2020-04-24 | 112 | 2020-06-09 | 2020-06-10 | 2d | 0d |  | Estefanía Castillo | 16h | 64,000 | 320,000 |
| 114 | 2.1.4 | Plan de Capacitación Entregado | milestone | 0d | 2020-04-24 | 2020-04-24 | 113 |  |  |  | 1d |  |  |  |  |  |
| 115 | 2.2 | **Manual de Usuario** |  | 9d | 2020-04-15 | 2020-04-27 |  | 2020-05-26 | 2020-06-11 | 13d | 0d |  |  | 64h | 320,000 | 4,512,000 |
| 116 | 2.2.1 | Realizar manual de usuario con flujos de operación |  | 3d | 2020-04-15 | 2020-04-17 | 105, 106, 107, 108 | 2020-05-26 | 2020-05-28 | 3d | 3d | 0d | Jeniffer Cruz | 24h | 96,000 | 1,656,000 |
| 117 | 2.2.2 | Presentar manual al negocio |  | 1d | 2020-04-20 | 2020-04-20 | 116 | 2020-05-29 | 2020-05-29 | 1d | 3d | 0d | Jeniffer Cruz | 8h | 32,000 | 552,000 |
| 118 | 2.2.3 | Ajustar manual |  | 1d | 2020-04-21 | 2020-04-21 | 117 | 2020-06-01 | 2020-06-02 | 2d | 3d |  | Jeniffer Cruz | 8h | 32,000 | 1,104,000 |
| 119 | 2.2.4 | Formalizar apobación de Plan y Manual |  | 1d | 2020-04-27 | 2020-04-27 | 113, 118 | 2020-06-11 | 2020-06-11 | 1d | 0d |  | Estefanía Castillo; Angel Pereira; Jeniffer Cruz | 24h | 160,000 | 1,200,000 |
| 120 | 2.2.5 | Manual de Usuario Entregado | milestone | 0d | 2020-04-27 | 2020-04-27 | 119 |  |  |  | 0d |  |  |  |  |  |
| 121 | 2.3 | **Simulador** |  | 8d | 2020-04-28 | 2020-05-08 |  | 2020-06-12 | 2020-06-17 | 3d | 0d |  |  | 56h | 2,016,000 | 3,120,000 |
| 122 | 2.3.1 | Realizar pruebas finales en el Simulador |  | 2d | 2020-04-28 | 2020-04-29 | 114, 120 | 2020-06-12 | 2020-06-16 | 2d | 0d |  | Product Owner; Scrum Master | 32h | 1,856,000 | 2,080,000 |
| 123 | 2.3.2 | Documentar conclusiones de sesión de Pruebas |  | 1d | 2020-04-30 | 2020-04-30 | 122 | 2020-06-17 | 2020-06-17 | 1d | 0d |  | Angel Pereira; Estefanía Castillo; Jeniffer Cruz | 24h | 160,000 | 1,040,000 |
| 124 | 2.3.3 | Estabilizar Sistema |  | 5d | 2020-05-04 | 2020-05-08 | 123 |  |  |  | 0d |  |  |  |  |  |

| ID | WBS | Task | Type | Duration | Start | Finish | Predecessors | Baseline start | Baseline finish | Baseline duration | Total slack | Free slack | Constraint | Resources | Work | Cost | Baseline cost |
| --- | --- | --- | --- | --- | --- | --- | --- | --- | --- | --- | --- | --- | --- | --- | --- | --- | --- |
| 125 | 3 | **Dirección de Proyectos** |  | 180d | 2019-09-16 | 2020-06-08 |  | 2019-09-16 | 2020-06-26 | 193d | 0d |  |  |  | 2320h | 16,064,000 | 14,112,000 |
| 126 | 3.1 | **Inicio** |  | 2d | 2019-09-16 | 2019-09-17 |  | 2019-09-16 | 2019-09-18 | 3d | 1d |  |  |  | 16h | 192,000 | 480,000 |
| 127 | 3.1.1 | Inicio Proyecto | milestone | 0d | 2019-09-16 | 2019-09-16 |  | 2019-09-16 | 2019-09-16 | 0d | 1d | 0d | start no earlier than 2019-09-16 |  |  |  |  |
| 128 | 3.1.2 | Project Charter |  | 2d | 2019-09-16 | 2019-09-17 | 127 | 2019-09-16 | 2019-09-18 | 3d | 1d | 0d |  | Angel Pereira | 16h | 192,000 | 480,000 |
| 129 | 3.2 | **Planeación** |  | 83d | 2019-09-18 | 2020-01-20 |  | 2019-09-19 | 2020-01-10 | 77d | 1d |  |  |  | 1712h | 11,840,000 | 11,232,000 |
| 130 | 3.2.1 | **Interesados** |  | 4d | 2019-09-18 | 2019-09-23 |  | 2019-09-19 | 2019-09-24 | 4d | 1d |  |  |  | 56h | 224,000 | 256,000 |
| 131 | 3.2.1.1 | Identificar los Interesados |  | 1d | 2019-09-18 | 2019-09-18 | 128 | 2019-09-19 | 2019-09-19 | 1d | 1d | 0d |  | Jeniffer Cruz | 8h | 32,000 | 64,000 |
| 132 | 3.2.1.2 | Realizar el Plan de Interesados |  | 1d | 2019-09-19 | 2019-09-19 | 131 | 2019-09-20 | 2019-09-20 | 1d | 1d | 0d |  | Estefanía Castillo; Jeniffer Cruz | 16h | 64,000 | 64,000 |
| 133 | 3.2.1.3 | Crear Matriz de Interesados |  | 1d | 2019-09-20 | 2019-09-20 | 132 | 2019-09-23 | 2019-09-23 | 1d | 1d | 0d |  | Estefanía Castillo; Jeniffer Cruz | 16h | 64,000 | 64,000 |
| 134 | 3.2.1.4 | Realizar plan de Involucramiento de Interesados |  | 1d | 2019-09-23 | 2019-09-23 | 133 | 2019-09-24 | 2019-09-24 | 1d | 1d | 0d |  | Estefanía Castillo; Jeniffer Cruz | 16h | 64,000 | 64,000 |
| 135 | 3.2.2 | **Integración** |  | 8d | 2019-09-18 | 2019-09-27 |  | 2019-09-19 | 2019-10-01 | 9d | 1d |  |  |  | 40h | 480,000 | 576,000 |
| 136 | 3.2.2.1 | **Plan de Dirección del Proyecto** |  | 8d | 2019-09-18 | 2019-09-27 |  | 2019-09-19 | 2019-10-01 | 9d | 1d |  |  |  | 40h | 480,000 | 576,000 |
| 137 | 3.2.2.1.1 | Recopilar Información |  | 1d | 2019-09-18 | 2019-09-18 | 128 | 2019-09-19 | 2019-09-19 | 1d | 4d | 3d |  | Angel Pereira | 8h | 96,000 | 96,000 |
| 138 | 3.2.2.1.2 | Establecer el plan para la dirección del Proyecto |  | 2d | 2019-09-24 | 2019-09-25 | 137, 132, 134 | 2019-09-25 | 2019-09-27 | 3d | 1d | 0d |  | Angel Pereira | 16h | 192,000 | 288,000 |
| 139 | 3.2.2.1.3 | Formalizar el Ciclo de Vida de Proyecto |  | 2d | 2019-09-26 | 2019-09-27 | 138 | 2019-09-30 | 2019-10-01 | 2d | 1d | 0d |  | Angel Pereira | 16h | 192,000 | 192,000 |
| 140 | 3.2.3 | **Alcance** |  | 18d | 2019-09-30 | 2019-10-24 |  | 2019-10-02 | 2019-10-29 | 19d | 1d |  |  |  | 416h | 2,816,000 | 2,976,000 |
| 141 | 3.2.3.1 | **Plan de Alcance** |  | 5d | 2019-09-30 | 2019-10-04 |  | 2019-10-02 | 2019-10-08 | 5d | 1d |  |  |  | 120h | 800,000 | 800,000 |
| 142 | 3.2.3.1.1 | Recopilar y analizar información |  | 1d | 2019-09-30 | 2019-09-30 | 128, 139, 138 | 2019-10-02 | 2019-10-02 | 1d | 1d | 0d |  | Angel Pereira; Estefanía Castillo; Jeniffer Cruz | 24h | 160,000 | 160,000 |
| 143 | 3.2.3.1.2 | Establecer el plan de Alcance |  | 4d | 2019-10-01 | 2019-10-04 | 142 | 2019-10-03 | 2019-10-08 | 4d | 1d | 0d |  | Angel Pereira; Estefanía Castillo; Jeniffer Cruz | 96h | 640,000 | 640,000 |
| 144 | 3.2.3.2 | **WBS** |  | 9d | 2019-10-07 | 2019-10-18 |  | 2019-10-09 | 2019-10-22 | 9d | 1d |  |  |  | 216h | 1,440,000 | 1,440,000 |
| 145 | 3.2.3.2.1 | Recopilar Requisitos |  | 2d | 2019-10-07 | 2019-10-08 | 128, 143 | 2019-10-09 | 2019-10-10 | 2d | 1d | 0d |  | Angel Pereira; Estefanía Castillo; Jeniffer Cruz | 48h | 320,000 | 320,000 |
| 146 | 3.2.3.2.2 | Definir el Alcance |  | 2d | 2019-10-09 | 2019-10-10 | 145 | 2019-10-11 | 2019-10-15 | 2d | 1d | 0d |  | Angel Pereira; Estefanía Castillo; Jeniffer Cruz | 48h | 320,000 | 320,000 |
| 147 | 3.2.3.2.3 | Descomponer el alcance en entregables |  | 2d | 2019-10-11 | 2019-10-15 | 139, 142, 146 | 2019-10-16 | 2019-10-17 | 2d | 1d | 0d |  | Angel Pereira; Estefanía Castillo; Jeniffer Cruz | 48h | 320,000 | 320,000 |
| 148 | 3.2.3.2.4 | Descomponer a release por entregable |  | 1d | 2019-10-16 | 2019-10-16 | 147 | 2019-10-18 | 2019-10-18 | 1d | 1d | 0d |  | Angel Pereira; Estefanía Castillo; Jeniffer Cruz | 24h | 160,000 | 160,000 |
| 149 | 3.2.3.2.5 | Identificar los paquetes de trabajo necesarios por release |  | 1d | 2019-10-17 | 2019-10-17 | 148 | 2019-10-21 | 2019-10-21 | 1d | 1d | 0d |  | Angel Pereira; Estefanía Castillo; Jeniffer Cruz | 24h | 160,000 | 160,000 |
| 150 | 3.2.3.2.6 | Revisar WBS |  | 1d | 2019-10-18 | 2019-10-18 | 149 | 2019-10-22 | 2019-10-22 | 1d | 1d | 0d |  | Angel Pereira; Estefanía Castillo; Jeniffer Cruz | 24h | 160,000 | 160,000 |
| 151 | 3.2.3.2.7 | 1ra Sustentación 1er Semestre | milestone | 0d | 2019-10-18 | 2019-10-18 | 150 | 2019-10-22 | 2019-10-22 | 0d | 1d | 0d |  |  |  |  |  |

| ID | WBS | Task | Duration | Start | Finish | Predecessors | Baseline start | Baseline finish | Baseline duration | Total slack | Free slack | Resources | Work | Cost | Baseline cost |
| --- | --- | --- | --- | --- | --- | --- | --- | --- | --- | --- | --- | --- | --- | --- | --- |
| 152 | 3.2.3.3 | **Diccionario de la WBS** | 3d | 2019-10-21 | 2019-10-23 |  | 2019-10-23 | 2019-10-28 | 4d | 1d |  |  | 48h | 192,000 | 256,000 |
| 153 | 3.2.3.3.1 | Identificar los paquetes de trabajo de la WBS | 1d | 2019-10-21 | 2019-10-21 | 143, 151 | 2019-10-23 | 2019-10-23 | 1d | 1d | 0d | Estefanía Castillo; Jeniffer Cruz | 16h | 64,000 | 64,000 |
| 154 | 3.2.3.3.2 | Detallar en el formato de diccionario la información de los paquetes | 2d | 2019-10-22 | 2019-10-23 | 153 | 2019-10-24 | 2019-10-28 | 3d | 1d | 0d | Estefanía Castillo; Jeniffer Cruz | 32h | 128,000 | 192,000 |
| 155 | 3.2.3.4 | **Enunciado del Alcance** | 1d | 2019-10-21 | 2019-10-21 |  | 2019-10-23 | 2019-10-24 | 2d | 1d |  |  | 8h | 96,000 | 192,000 |
| 156 | 3.2.3.4.1 | Documentar el enunciado del Alcance | 1d | 2019-10-21 | 2019-10-21 | 139, 143, 145, 150 | 2019-10-23 | 2019-10-23 | 1d | 1d | 0d | Angel Pereira | 8h | 96,000 | 96,000 |
| 157 | 3.2.3.5 | **Product Backlog** | 3d | 2019-10-22 | 2019-10-24 |  | 2019-10-25 | 2019-10-29 | 3d | 1d |  |  | 24h | 288,000 | 288,000 |
| 158 | 3.2.3.5.1 | Establecer la Pila de Producto | 1d | 2019-10-22 | 2019-10-22 | 139, 143, 145, 150, 156 | 2019-10-25 | 2019-10-25 | 1d | 1d | 0d | Angel Pereira | 8h | 96,000 | 96,000 |
| 159 | 3.2.3.5.2 | Crear Matriz de Trazabilidad de Requisitos | 1d | 2019-10-23 | 2019-10-23 | 158 | 2019-10-28 | 2019-10-28 | 1d | 1d | 0d | Angel Pereira | 8h | 96,000 | 96,000 |
| 160 | 3.2.3.5.3 | Formalizar Línea Base de Alcance | 1d | 2019-10-24 | 2019-10-24 | 150, 154, 156, 159 | 2019-10-29 | 2019-10-29 | 1d | 1d | 0d | Angel Pereira | 8h | 96,000 | 96,000 |
| 161 | 3.2.4 | **Cronograma** | 12d | 2019-10-25 | 2019-11-13 |  | 2019-10-30 | 2019-11-19 | 13d | 1d |  |  | 200h | 1,568,000 | 1,664,000 |
| 162 | 3.2.4.1 | **Plan de Cronograma** | 3d | 2019-10-25 | 2019-10-29 |  | 2019-10-30 | 2019-11-01 | 3d | 1d |  |  | 72h | 480,000 | 480,000 |
| 163 | 3.2.4.1.1 | Recopilar y analizar información | 1d | 2019-10-25 | 2019-10-25 | 128, 143, 138, 158, 160 | 2019-10-30 | 2019-10-30 | 1d | 1d | 0d | Estefanía Castillo; Angel Pereira; Jeniffer Cruz | 24h | 160,000 | 160,000 |
| 164 | 3.2.4.1.2 | Establecer el Plan de Cronograma | 2d | 2019-10-28 | 2019-10-29 | 163 | 2019-10-31 | 2019-11-01 | 2d | 1d | 0d | Estefanía Castillo; Angel Pereira; Jeniffer Cruz | 48h | 320,000 | 320,000 |
| 165 | 3.2.4.2 | **Desarrollar el Cronograma** | 9d | 2019-10-30 | 2019-11-13 |  | 2019-11-05 | 2019-11-19 | 10d | 1d |  |  | 128h | 1,088,000 | 1,184,000 |
| 166 | 3.2.4.2.1 | Descomponer los paquetes de trabajo en actividades | 2d | 2019-10-30 | 2019-10-31 | 139, 150, 156, 158, 164 | 2019-11-05 | 2019-11-06 | 2d | 1d | 0d | Estefanía Castillo; Angel Pereira; Jeniffer Cruz | 48h | 320,000 | 320,000 |
| 167 | 3.2.4.2.2 | Listar Actividades | 1d | 2019-11-01 | 2019-11-01 | 166 | 2019-11-07 | 2019-11-07 | 1d | 1d | 0d | Estefanía Castillo; Angel Pereira; Jeniffer Cruz | 24h | 160,000 | 160,000 |
| 168 | 3.2.4.2.3 | Secuenciar Actividades | 1d | 2019-11-05 | 2019-11-05 | 167 | 2019-11-08 | 2019-11-12 | 2d | 1d | 0d | Angel Pereira | 8h | 96,000 | 192,000 |
| 169 | 3.2.4.2.4 | Estimar recursos | 2d | 2019-11-06 | 2019-11-07 | 167, 168 | 2019-11-13 | 2019-11-14 | 2d | 1d | 0d | Angel Pereira | 16h | 192,000 | 192,000 |
| 170 | 3.2.4.2.5 | Estimar duración de actividades | 2d | 2019-11-08 | 2019-11-12 | 168, 169 | 2019-11-15 | 2019-11-18 | 2d | 1d | 0d | Angel Pereira | 16h | 192,000 | 192,000 |
| 171 | 3.2.4.2.6 | Formalizar Línea Base del Cronograma | 1d | 2019-11-13 | 2019-11-13 | 170 | 2019-11-19 | 2019-11-19 | 1d | 1d | 0d | Angel Pereira; Jeniffer Cruz | 16h | 128,000 | 128,000 |
| 172 | 3.2.5 | **Recursos** | 7d | 2019-11-05 | 2019-11-14 |  | 2019-11-08 | 2019-11-20 | 8d | 10d |  |  | 56h | 224,000 | 256,000 |
| 173 | 3.2.5.1 | **Plan de Recursos** | 7d | 2019-11-05 | 2019-11-14 |  | 2019-11-08 | 2019-11-20 | 8d | 10d |  |  | 56h | 224,000 | 256,000 |
| 174 | 3.2.5.1.1 | Recopilar y analizar información | 1d | 2019-11-05 | 2019-11-05 | 128, 143, 164, 138, 167 | 2019-11-08 | 2019-11-08 | 1d | 10d | 0d | Estefanía Castillo | 8h | 32,000 | 32,000 |
| 175 | 3.2.5.1.2 | Establecer el Plan de Recursos | 2d | 2019-11-06 | 2019-11-07 | 174 | 2019-11-12 | 2019-11-13 | 2d | 10d | 0d | Estefanía Castillo | 16h | 64,000 | 64,000 |
| 176 | 3.2.5.1.3 | Asignar roles y responsabilidades | 1d | 2019-11-08 | 2019-11-08 | 175 | 2019-11-14 | 2019-11-15 | 2d | 10d | 0d | Estefanía Castillo | 8h | 32,000 | 64,000 |
| 177 | 3.2.5.1.4 | Crear Matriz RACI | 2d | 2019-11-12 | 2019-11-13 | 176 | 2019-11-18 | 2019-11-19 | 2d | 10d | 0d | Estefanía Castillo | 16h | 64,000 | 64,000 |
| 178 | 3.2.5.1.5 | Revisar y ajustar plan | 1d | 2019-11-14 | 2019-11-14 | 177 | 2019-11-20 | 2019-11-20 | 1d | 10d |  | Estefanía Castillo | 8h | 32,000 | 32,000 |

| ID | WBS | Task | Duration | Start | Finish | Predecessors | Baseline start | Baseline finish | Baseline duration | Total slack | Free slack | Resources | Work | Cost | Baseline cost |
| --- | --- | --- | --- | --- | --- | --- | --- | --- | --- | --- | --- | --- | --- | --- | --- |
| 179 | 3.2.6 | **Riesgos** | 10d | 2019-11-14 | 2019-11-27 |  | 2019-11-26 | 2019-12-04 | 7d | 1d |  |  | 80h | 960,000 | 896,000 |
| 180 | 3.2.6.1 | **Plan de Riesgos** | 10d | 2019-11-14 | 2019-11-27 |  | 2019-11-26 | 2019-12-04 | 7d | 1d |  |  | 80h | 960,000 | 896,000 |
| 181 | 3.2.6.1.1 | Recopilar y analizar información | 2d | 2019-11-14 | 2019-11-15 | 128, 138, 143, 164, 160, 171, 198 | 2019-11-26 | 2019-11-26 | 1d | 1d | 0d | Angel Pereira | 16h | 192,000 | 128,000 |
| 182 | 3.2.6.1.2 | Establecer el Plan de Riesgos | 3d | 2019-11-18 | 2019-11-20 | 181 | 2019-11-27 | 2019-11-28 | 2d | 1d | 0d | Angel Pereira | 24h | 288,000 | 256,000 |
| 183 | 3.2.6.1.3 | Evaluar los riesgos del Proyecto | 2d | 2019-11-21 | 2019-11-22 | 182 | 2019-11-29 | 2019-12-03 | 3d | 3d | 0d | Angel Pereira | 16h | 192,000 | 384,000 |
| 184 | 3.2.6.1.4 | Crear la Matriz de Riesgos | 3d | 2019-11-25 | 2019-11-27 | 183 | 2019-12-04 | 2019-12-04 | 1d | 3d | 0d | Angel Pereira | 24h | 288,000 | 128,000 |
| 185 | 3.2.7 | **Costos** | 13d | 2019-11-21 | 2019-12-09 |  | 2019-11-29 | 2019-12-12 | 10d | 1d |  |  | 136h | 928,000 | 800,000 |
| 186 | 3.2.7.1 | **Plan de Costos** | 5d | 2019-11-21 | 2019-11-27 |  | 2019-11-29 | 2019-12-05 | 5d | 1d |  |  | 40h | 160,000 | 160,000 |
| 187 | 3.2.7.1.1 | Recopilar y analizar información | 2d | 2019-11-21 | 2019-11-22 | 128, 138, 143, 164, 160, 171, 182, 202, 197 | 2019-11-29 | 2019-12-02 | 2d | 1d | 0d | Jeniffer Cruz | 16h | 64,000 | 64,000 |
| 188 | 3.2.7.1.2 | Establecer el Plan de Costos | 3d | 2019-11-25 | 2019-11-27 | 187 | 2019-12-03 | 2019-12-05 | 3d | 1d | 0d | Jeniffer Cruz | 24h | 96,000 | 96,000 |
| 189 | 3.2.7.2 | **Presupuesto** | 8d | 2019-11-28 | 2019-12-09 |  | 2019-12-05 | 2019-12-12 | 6d | 1d |  |  | 96h | 768,000 | 640,000 |
| 190 | 3.2.7.2.1 | Estimar el costo del Proyecto | 4d | 2019-11-28 | 2019-12-03 | 175, 169, 178, 188 | 2019-12-06 | 2019-12-09 | 2d | 1d | 0d | Jeniffer Cruz | 32h | 128,000 | 64,000 |
| 191 | 3.2.7.2.2 | Estimar la reservas de contingencia y gestión | 2d | 2019-11-28 | 2019-11-29 | 184 | 2019-12-05 | 2019-12-06 | 2d | 3d | 2d | Angel Pereira | 16h | 192,000 | 192,000 |
| 192 | 3.2.7.2.3 | Establecer el Presupuesto | 3d | 2019-12-04 | 2019-12-06 | 190, 191 | 2019-12-11 | 2019-12-11 | 1d | 1d | 0d | Angel Pereira | 24h | 288,000 | 128,000 |
| 193 | 3.2.7.2.4 | Generar la Curva S | 1d | 2019-12-04 | 2019-12-04 | 190, 191 | 2019-12-10 | 2019-12-10 | 1d | 3d | 2d | Jeniffer Cruz | 8h | 32,000 | 32,000 |
| 194 | 3.2.7.2.5 | Formalizar la Línea base de Costos | 1d | 2019-12-09 | 2019-12-09 | 192, 193 | 2019-12-12 | 2019-12-12 | 1d | 1d | 0d | Angel Pereira; Jeniffer Cruz | 16h | 128,000 | 128,000 |
| 195 | 3.2.8 | **Comunicaciones** | 4d | 2019-11-05 | 2019-11-08 |  | 2019-11-08 | 2019-11-15 | 5d | 3d |  |  | 32h | 128,000 | 160,000 |
| 196 | 3.2.8.1 | Recopilar y analizar información | 1d | 2019-11-05 | 2019-11-05 | 128, 143, 164, 138, 167, 133, 134 | 2019-11-08 | 2019-11-08 | 1d | 3d | 0d | Jeniffer Cruz | 8h | 32,000 | 32,000 |
| 197 | 3.2.8.2 | Establecer el Plan de Comunicaciones | 2d | 2019-11-06 | 2019-11-07 | 196 | 2019-11-12 | 2019-11-14 | 3d | 3d | 0d | Jeniffer Cruz | 16h | 64,000 | 96,000 |
| 198 | 3.2.8.3 | Formalizar Plan de Comunicaciones | 1d | 2019-11-08 | 2019-11-08 | 197 | 2019-11-15 | 2019-11-15 | 1d | 3d | 2d | Jeniffer Cruz | 8h | 32,000 | 32,000 |
| 199 | 3.2.9 | **Calidad** | 6d | 2019-11-14 | 2019-11-21 |  | 2019-11-20 | 2019-11-28 | 7d | 3d |  |  | 48h | 192,000 | 224,000 |
| 200 | 3.2.9.1 | **Plan de Calidad** | 3d | 2019-11-14 | 2019-11-18 |  | 2019-11-20 | 2019-11-22 | 3d | 3d |  |  | 24h | 96,000 | 96,000 |
| 201 | 3.2.9.1.1 | Recopilar y analizar información | 1d | 2019-11-14 | 2019-11-14 | 128, 143, 164, 138, 167, 171 | 2019-11-20 | 2019-11-20 | 1d | 3d | 0d | Jeniffer Cruz | 8h | 32,000 | 32,000 |
| 202 | 3.2.9.1.2 | Establecer el Plan de Calidad | 2d | 2019-11-15 | 2019-11-18 | 201 | 2019-11-21 | 2019-11-22 | 2d | 3d | 0d | Jeniffer Cruz | 16h | 64,000 | 64,000 |

| ID | WBS | Task | Type | Duration | Start | Finish | Predecessors | Baseline start | Baseline finish | Baseline duration | Total slack | Free slack | Resources | Work | Cost | Baseline cost |
| --- | --- | --- | --- | --- | --- | --- | --- | --- | --- | --- | --- | --- | --- | --- | --- | --- |
| 203 | 3.2.9.2 | **Matriz de Indicadores** |  | 3d | 2019-11-19 | 2019-11-21 |  | 2019-11-25 | 2019-11-28 | 4d | 13d |  |  | 24h | 96,000 | 128,000 |
| 204 | 3.2.9.2.1 | Evaluar indicadores, metricas y atributos de calidad |  | 1d | 2019-11-19 | 2019-11-19 | 202, 167, 171 | 2019-11-25 | 2019-11-26 | 2d | 13d | 0d | Estefanía Castillo | 8h | 32,000 | 64,000 |
| 205 | 3.2.9.2.2 | Crear Matriz de Indicadores |  | 2d | 2019-11-20 | 2019-11-21 | 204 | 2019-11-27 | 2019-11-28 | 2d | 13d |  | Estefanía Castillo | 16h | 64,000 | 64,000 |
| 206 | 3.2.10 | **Actualización de Planes** |  | 27d | 2019-12-10 | 2020-01-20 |  | 2019-12-13 | 2020-01-10 | 19d | 1d |  |  | 648h | 4,320,000 | 3,040,000 |
| 207 | 3.2.10.1 | Actualizar Documentación de Planes y actividades |  | 25d | 2019-12-10 | 2020-01-16 | 128, 138, 143, 164, 160, 171, 182, 202, 197, 194, 205 | 2019-12-13 | 2019-12-18 | 4d | 1d | 0d | Estefanía Castillo; Angel Pereira; Jeniffer Cruz | 600h | 4,000,000 | 640,000 |
| 208 | 3.2.10.2 | Ajustar planes y refinar planicación de Proyecto |  | 2d | 2020-01-17 | 2020-01-20 | 207 | 2019-12-19 | 2020-01-10 | 15d | 1d | 0d | Estefanía Castillo; Angel Pereira; Jeniffer Cruz | 48h | 320,000 | 2,400,000 |
| 209 | 3.2.10.3 | Fin de Planeación | milestone | 0d | 2020-01-20 | 2020-01-20 | 208 | 2020-01-10 | 2020-01-10 | 0d | 1d | 0d |  |  |  |  |
| 210 | 3.3 | **Monitoreo y control** |  | 51d | 2020-02-27 | 2020-05-13 |  | 2020-03-06 | 2020-06-19 | 70d | 2d |  |  | 216h | 1,440,000 | 1,632,000 |
| 211 | 3.3.1 | **Seguimientos del Proyecto** |  | 51d | 2020-02-27 | 2020-05-13 |  | 2020-03-06 | 2020-06-19 | 70d | 2d |  |  | 216h | 1,440,000 | 1,632,000 |
| 212 | 3.3.1.1 | **Seguimientos Mensuales de Proyecto** |  | 49d | 2020-02-27 | 2020-05-11 |  | 2020-03-06 | 2020-06-12 | 66d | 2d |  |  | 72h | 480,000 | 544,000 |
| 213 | 3.3.1.1.1 | Realizar reunión de Seguimiento con Sponsor |  | 1d | 2020-02-27 | 2020-02-27 | 54 | 2020-03-06 | 2020-03-06 | 1d | 50d | 0d | Estefanía Castillo; Angel Pereira; Jeniffer Cruz | 24h | 160,000 | 160,000 |
| 214 | 3.3.1.1.2 | Realizar reunión de Seguimiento con Sponsor 2 |  | 1d | 2020-03-26 | 2020-03-26 | 88 | 2020-04-08 | 2020-04-08 | 1d | 31d | 0d | Estefanía Castillo; Angel Pereira; Jeniffer Cruz | 24h | 160,000 | 160,000 |
| 215 | 3.3.1.1.3 | Realizar reunión de Seguimiento con Sponsor 3 |  | 1d | 2020-05-11 | 2020-05-11 | 124 | 2020-05-06 | 2020-05-06 | 1d | 0d |  | Estefanía Castillo; Angel Pereira; Jeniffer Cruz | 24h | 160,000 | 160,000 |
| 216 | 3.3.1.2 | **Reuniones TDG** |  | 49d | 2020-02-28 | 2020-05-12 |  | 2020-03-09 | 2020-06-18 | 68d | 2d |  |  | 72h | 480,000 | 576,000 |
| 217 | 3.3.1.2.1 | Reunión TDG 1 |  | 1d | 2020-02-28 | 2020-02-28 | 213 | 2020-03-09 | 2020-03-09 | 1d | 50d | 0d | Estefanía Castillo; Angel Pereira; Jeniffer Cruz | 24h | 160,000 | 160,000 |
| 218 | 3.3.1.2.2 | Reunión TDG 2 |  | 1d | 2020-03-27 | 2020-03-27 | 214 | 2020-04-13 | 2020-04-13 | 1d | 31d | 0d | Estefanía Castillo; Angel Pereira; Jeniffer Cruz | 24h | 160,000 | 160,000 |
| 219 | 3.3.1.2.3 | Reunión TDG 3 |  | 1d | 2020-05-12 | 2020-05-12 | 215 | 2020-05-07 | 2020-05-07 | 1d | 0d |  | Estefanía Castillo; Angel Pereira; Jeniffer Cruz | 24h | 160,000 | 160,000 |
| 220 | 3.3.1.3 | **Informes de Proyecto** |  | 49d | 2020-03-02 | 2020-05-13 |  | 2020-03-10 | 2020-06-19 | 68d | 2d |  |  | 72h | 480,000 | 512,000 |
| 221 | 3.3.1.3.1 | Generar Informe de Seguimiento |  | 1d | 2020-03-02 | 2020-03-02 | 217 | 2020-03-10 | 2020-03-10 | 1d | 50d |  | Estefanía Castillo; Angel Pereira; Jeniffer Cruz | 24h | 160,000 | 160,000 |
| 222 | 3.3.1.3.2 | Generar Informe de Seguimiento |  | 1d | 2020-03-30 | 2020-03-30 | 218 | 2020-04-14 | 2020-04-14 | 1d | 31d |  | Estefanía Castillo; Angel Pereira; Jeniffer Cruz | 24h | 160,000 | 160,000 |
| 223 | 3.3.1.3.3 | Generar Informe de Seguimiento |  | 1d | 2020-05-13 | 2020-05-13 | 219 | 2020-05-08 | 2020-05-08 | 1d | 0d |  | Estefanía Castillo; Angel Pereira; Jeniffer Cruz | 24h | 160,000 | 160,000 |
| 224 | 3.4 | **Cierre del proyecto** |  | 17d | 2020-05-14 | 2020-06-08 |  | 2020-06-18 | 2020-06-26 | 6d | 0d |  |  | 376h | 2,592,000 | 768,000 |
| 225 | 3.4.1 | Realizar Acta de Cierre |  | 2d | 2020-05-14 | 2020-05-15 | 223 | 2020-06-18 | 2020-06-23 | 3d | 0d |  | Angel Pereira | 16h | 192,000 | 288,000 |
| 226 | 3.4.2 | Realizar el registro de Lecciones Aprendidas |  | 1d | 2020-05-18 | 2020-05-18 | 225, 221, 222, 223 | 2020-06-24 | 2020-06-24 | 1d | 0d |  | Estefanía Castillo; Angel Pereira; Jeniffer Cruz | 24h | 160,000 | 160,000 |
| 227 | 3.4.3 | Preparación Informes Sustentación Final |  | 14d | 2020-05-19 | 2020-06-08 | 226 | 2020-06-25 | 2020-06-26 | 2d | 0d |  | Estefanía Castillo; Angel Pereira; Jeniffer Cruz | 336h | 2,240,000 | 320,000 |
| 228 | 3.4.4 | Fin de Proyecto | milestone | 0d | 2020-06-08 | 2020-06-08 | 227 | 2020-06-26 | 2020-06-26 | 0d | 0d |  |  |  |  |  |
